Schedule from MS Project, 2025-09-01 to 2025-12-31, status date 2025-09-01, 9.5 hours a day, A marks actual dates.

## Calendars

- SUPERCADE AMERICAS: Mon-Fri 07:00-13:00, 14:00-17:30; Sat 07:00-12:00; Sun off. Exceptions (off unless hours are given): 2025-10-13, 2025-11-03, 2025-11-17, 2025-12-08, 2025-12-25.

## Resources

| Resource |
| --- |
| OPERARIO MAQ |
| AYUDANTE |
| ESPEC. PATOLOGIA |
| ESPEC. GEOTECNISTA |
| LAVADOR DE FACHADAS |
| ESPEC. ESTRUCTURAL - ING. CIVIL |
| RESIDENTE DE OBRA |
| DIRECTOR DE OBRA |
| ESPEC. HIDRAULICO |
| ESPEC. ELECTRICO |
| ESPEC. MECANICO |
| EQUIPO TOPOGRAFIA |
| INTERVENTORIA |
| OFICIAL DE OBRA |
| SU`PERVISIO |
| SUPERVISION |

## Schedule

| ID | Task | Type | Duration | Start | Finish | Predecessors | Complete | Remaining | Baseline start | Baseline finish | Baseline duration | Total slack | Constraint | Deadline |
| --- | --- | --- | --- | --- | --- | --- | --- | --- | --- | --- | --- | --- | --- | --- |
| 1 | OBRAS DE EJECUCION DE CUBIERTA Y SISTEMA DE AGUAS LLUVIAS SUPERCADE AMERICAS, BOGOTA, D.C. | manual | 91d | 2025-09-01 A | 2025-12-31 |  | 1% | 90.32d | 2025-09-01 | 2025-12-31 | 91d |  |  |  |
| 2 | 1. ACTIVIDADES PRELIMINARES |  | 91d | 2025-09-01 A | 2025-12-31 | 1SS | 1% | 90d | 2025-09-01 | 2025-12-31 | 91d | 0d |  |  |
| 3 | LOCALIZACIÓN Y REPLANTEO | manual | 15d | 2025-09-01 A | 2025-09-18 | 2SS | 7% | 14d | 2025-09-01 | 2025-09-18 | 15d |  | start no earlier than 2025-09-01 |  |
| 4 | ASEO Y LIMPIEZA | manual | 91d | 2025-09-01 A | 2025-12-31 | 3SS | 1% | 90.21d | 2025-09-01 | 2025-12-31 | 91d |  | start no earlier than 2025-09-01 |  |
| 5 | CAMPAMENTO PROVISIONAL | manual | 90d | 2025-09-01 A | 2025-12-31 | 2SS | 1% | 89.32d | 2025-09-01 | 2025-12-31 | 90d |  | start no earlier than 2025-09-01 |  |
| 6 | BAÑO PORTATIL | manual | 87d? | 2025-09-01 A | 2025-12-31 | 5SS | 1% | 86.32d? | 2025-09-01 | 2025-12-31 | 87d |  | start no earlier than 2025-09-01 | 2025-03-31 |
| 7 | CERRAMIENTO | manual | 91d | 2025-09-01 A | 2025-12-31 | 6SS | 1% | 90d | 2025-09-01 | 2025-12-31 | 91d |  |  |  |
| 8 | SEÑALIZACIÓN DE OBRA | manual | 91d | 2025-09-01 A | 2025-12-31 | 7SS | 1% | 90d | 2025-09-01 | 2025-12-31 | 91d |  |  |  |
| 9 | PLAN DE MANEJO AMBIENTAL Y SG-SST -Cumplimiento Estandares Minimos SG-SST |  | 91d | 2025-09-01 A | 2025-12-31 | 8SS | 1% | 90d | 2025-09-01 | 2025-12-31 | 91d | 0d |  |  |
| 10 | 2. DEMOLICIONES, DESMONTES Y RETIROS |  | 30d | 2025-09-16 | 2025-10-25 | 2SS+13d |  |  | 2025-09-16 | 2025-10-24 | 30d | 0d | start no earlier than 2025-09-16 |  |
| 11 | RETIRO DE MATERIAL VEGETAL EN CANAL EXISTENTES |  | 8d | 2025-09-16 | 2025-09-26 | 10SS |  |  | 2025-10-09 | 2025-10-21 | 8d | 0d | start no earlier than 2025-09-16 |  |
| 12 | 3. EXCAVACIONES Y RELLENOS |  | 25d | 2025-09-23 | 2025-10-24 |  |  |  | 2025-09-23 | 2025-10-24 | 25d | 0d | start no earlier than 2025-09-23 |  |
| 13 | EXCAVACIÓN MANUAL |  | 12d | 2025-09-23 | 2025-10-07 | 12SS |  |  | 2025-09-23 | 2025-10-07 | 12d | 0d | start no earlier than 2025-09-23 |  |
| 14 | RELLENO EN MATERIAL GRANULAR |  | 13d | 2025-10-07 | 2025-10-24 | 13 |  |  | 2025-10-07 | 2025-10-24 | 13d | 0d |  |  |
| 15 | 4. REFORZAMIENTO ESTRUCTURAL DE CUBIERTA EN ACERO |  | 45d | 2025-09-23 | 2025-11-21 | 13SS |  |  | 2025-09-23 | 2025-11-21 | 45d | 0d | start no earlier than 2025-09-23 |  |
| 16 | PERFILES TUBULARES DE Ø 2.5" CON CONEXIÓN PERNADA DE CUBIERTA |  | 45d | 2025-09-23 | 2025-11-21 | 15SS |  |  | 2025-09-23 | 2025-11-21 | 45d | 0d | start no earlier than 2025-09-23 |  |
| 17 | RETIRO DE TEJA DE CUBIERTA EXISTENTE |  | 25d | 2025-10-02 | 2025-11-05 | 16SS+8d |  |  | 2025-10-02 | 2025-11-05 | 25d | 0d | start no earlier than 2025-09-16 |  |
| 18 | 5. CUBIERTA |  | 35d | 2025-11-05 | 2025-12-22 | 16SS+20d |  |  | 2025-11-05 | 2025-12-22 | 35d | 0d | start no earlier than 2025-11-05 |  |
| 19 | SUMINISTRO E INSTALACION DE TEJA TIPO SANDWICH |  | 25d | 2025-11-05 | 2025-12-10 | 17 |  |  | 2025-11-05 | 2025-12-09 | 25d | 0d | start no earlier than 2025-11-05 |  |
| 20 | SUMINISTRO E INSTALACION DE TEJA EN POLICABONATO EN LUCARNA (Marquesina Superior) |  | 5d | 2025-12-10 | 2025-12-17 | 19 |  |  | 2025-12-09 | 2025-12-16 | 5d | 0d | start no earlier than 2025-12-01 |  |
| 21 | 6. CAJAS DE INSPECCIÓN |  | 45d | 2025-10-15 A | 2025-12-15 A | 13SS+5d | 100% |  | 2024-10-15 | 2024-12-10 | 45d |  | start no earlier than 2024-10-15 |  |
| 22 | MODIFICACIÓN Y ADECUACION DE CAJAS DE INSPECCIÓN |  | 45d | 2025-10-15 | 2025-12-15 | 21SS |  |  | 2025-10-15 | 2025-12-15 | 45d | 0d | start no earlier than 2025-10-15 |  |
| 23 | 7. TUBERIAS SANITARIAS |  | 45d | 2025-10-15 | 2025-12-15 | 21SS |  |  | 2025-10-15 | 2025-12-15 | 45d | 0d | start no earlier than 2025-10-15 |  |
| 24 | DEMOLICIÓN DE ANDEN EXISTENTES |  | 45d | 2025-10-15 | 2025-12-15 | 23SS |  |  | 2025-10-15 | 2025-12-15 | 45d | 0d | start no earlier than 2025-10-15 |  |
| 25 | RETIRO DE TUBERIA EXISTENTES EN CAJAS DE INSPECCIÓN |  | 45d | 2025-10-15 | 2025-12-15 | 24SS |  |  | 2025-10-15 | 2025-12-15 | 45d | 0d | start no earlier than 2025-09-23 |  |
| 26 | SUMINISTRO E INSTALACIÓN DE TUBERIA 6" |  | 45d | 2025-10-15 | 2025-12-15 | 25SS |  |  | 2025-10-15 | 2025-12-15 | 45d | 0d | start no earlier than 2025-10-15 |  |
| 27 | SUMINISTRO E INSTALACIÓN DE TUBERIA 8" |  | 45d | 2025-10-15 | 2025-12-15 | 25SS |  |  | 2025-10-15 | 2025-12-15 | 45d | 0d | start no earlier than 2025-10-15 |  |
| 28 | SUMINISTRO E INSTALACIÓN DE TUBERIA 10" |  | 45d | 2025-10-15 | 2025-12-15 | 27SS |  |  | 2025-10-15 | 2025-12-15 | 45d | 0d | start no earlier than 2025-10-15 |  |
| 29 | 8. ANDÉN |  | 45d | 2025-10-15 | 2025-12-15 | 23SS |  |  | 2025-10-15 | 2025-12-15 | 45d | 0d | start no earlier than 2025-10-15 |  |
| 30 | CONSTRUCCION DE ANDENES |  | 45d | 2025-10-15 | 2025-12-15 | 29SS |  |  | 2025-10-15 | 2025-12-15 | 45d | 0d | start no earlier than 2025-10-15 |  |
